# Planeacion proyecto

Schedule from MS Project, 2011-01-05 to 2011-02-18, A marks actual dates.

## Calendars

- Estándar: Mon-Fri 09:00-13:00, 15:00-19:00; Sat-Sun off.

## Resources

| Resource |
| --- |
| Jorge Alberto Alejandro Mendez |
| Juan Alberto Alcudia Mendoza |
| Fausto Hernandez Gonzalez |
| Maria del Carmen Flota Leon |
| Patricia Martinez Guzman |
| Laptops para Curso |
| Memorias USB |
| Carol Heredia Gracias |

## Schedule

| ID | WBS | Task | Duration | Start | Finish | Predecessors | Complete | Remaining | Baseline 1 start | Baseline 1 finish | Total slack | Free slack | Constraint | Resources | Work | Actual work |
| --- | --- | --- | --- | --- | --- | --- | --- | --- | --- | --- | --- | --- | --- | --- | --- | --- |
| 1 | 1 | **CAPACITACION SPDIS EN REGION SUR** | 32.62d? | 2011-01-05 A | 2011-02-18 |  | 46% | 17.75d? | 2011-01-05 | 2011-02-18 | 0d |  |  |  | 277.4h | 129.16h |
| 2 | 1.1 | **PREPARACION PARA CURSO** | 24.62d? | 2011-01-05 A | 2011-02-08 |  | 56% | 10.85d? | 2011-01-05 | 2011-02-08 | 8d |  |  |  | 36.3h | 27.66h |
| 3 | 1.1.1 | Recoleccion de Datos del Personal | 1.62d? | 2011-01-05 A | 2011-01-06 A |  | 100% |  | 2011-01-05 | 2011-01-11 |  |  | finish no earlier than 2011-01-11 | Carol Heredia Gracias [50%] | 6.5h | 6.5h |
| 4 | 1.1.2 | Difusion del Curso | 19.62d? | 2011-01-12 A | 2011-02-08 | 3 | 45% | 10.79d? | 2011-01-12 | 2011-02-08 | 8d |  | finish no earlier than 2011-02-08 | Jorge Alberto Alejandro Mendez [10%] | 15.7h | 7.07h |
| 5 | 1.1.3 | Preparacion de Equipo a utilizar | 2.62d? | 2011-01-12 A | 2011-01-14 A | 3 | 100% |  | 2011-01-12 | 2011-01-14 |  |  | finish no earlier than 2011-01-14 | Fausto Hernandez Gonzalez [20%]; Jorge Alberto Alejandro Mendez [20%]; Juan Alberto Alcudia Mendoza [20%] | 12.6h | 12.6h |
| 6 | 1.1.4 | Verificar Red de datos en Instalaciones de IMP | 0.62d? | 2011-01-17 A | 2011-01-17 A | 5 | 100% |  | 2011-01-17 | 2011-01-17 |  |  | finish no earlier than 2011-01-17 | Juan Alberto Alcudia Mendoza [15%]; Jorge Alberto Alejandro Mendez [15%] | 1.5h | 1.5h |
| 7 | 1.2 | **DESARROLLO DE CURSO** | 23.62d? | 2011-01-18 A | 2011-02-18 | 6 | 41% | 13.98d? | 2011-01-18 | 2011-02-18 | 0d |  |  |  | 241.1h | 101.5h |
| 8 | 1.2.1 | **MUSPAC, UO REFORMA, SAMARIA-LUNA** | 5.44d? | 2011-01-18 A | 2011-01-25 A | 6 | 100% |  | 2011-01-18 | 2011-01-25 |  |  |  |  | 56.55h | 56.55h |
| 9 | 1.2.1.1 | Imparticion de Capacitacion | 3.62d? | 2011-01-18 A | 2011-01-21 A | 6 | 100% |  | 2011-01-18 | 2011-01-21 |  |  | finish no earlier than 2011-01-21 | Maria del Carmen Flota Leon [50%]; Patricia Martinez Guzman [50%] | 29h | 29h |
| 10 | 1.2.1.2 | Apoyo Logistico | 3.62d? | 2011-01-18 A | 2011-01-21 A | 9SS | 100% |  | 2011-01-18 | 2011-01-21 |  |  | finish no earlier than 2011-01-21 | Carol Heredia Gracias [35%] | 10.15h | 10.15h |
| 11 | 1.2.1.3 | Apoyo Tecnico | 5.44d? | 2011-01-18 A | 2011-01-25 A | 10SS | 100% |  | 2011-01-18 | 2011-01-25 |  |  | finish no earlier than 2011-01-21 | Jorge Alberto Alejandro Mendez [20%]; Juan Alberto Alcudia Mendoza [20%] | 17.4h | 17.4h |
| 12 | 1.2.2 | **AI MACUSPANA, UO CD PEMEX** | 3.62d? | 2011-01-25 A | 2011-01-31 A |  | 100% |  | 2011-01-25 | 2011-01-31 |  |  |  |  | 44.95h | 44.95h |
| 13 | 1.2.2.1 | Imparticion de Capacitacion | 3.62d? | 2011-01-25 A | 2011-01-31 A | 11 | 100% |  | 2011-01-25 | 2011-01-31 |  |  | finish no earlier than 2011-01-28 | Maria del Carmen Flota Leon [50%]; Patricia Martinez Guzman [50%] | 29h | 29h |
| 14 | 1.2.2.2 | Apoyo Logistico | 3.62d? | 2011-01-25 A | 2011-01-31 A | 13SS | 100% |  | 2011-01-25 | 2011-01-31 |  |  | finish no earlier than 2011-01-28 | Carol Heredia Gracias [35%] | 10.15h | 10.15h |
| 15 | 1.2.2.3 | Apoyo Tecnico | 1.81d? | 2011-01-26 A | 2011-01-28 A | 14SS | 100% |  | 2011-01-26 | 2011-01-28 |  |  | finish no earlier than 2011-01-28 | Jorge Alberto Alejandro Mendez [20%]; Juan Alberto Alcudia Mendoza [20%] | 5.8h | 5.8h |
| 16 | 1.2.3 | **SAMARIA LUNA, BELLOTA-JUJO, UO COMALCALCO** | 3.62d? | 2011-02-02 | 2011-02-08 |  |  |  | 2011-02-02 | 2011-02-08 | 5.88d |  |  |  | 29h |  |
| 17 | 1.2.3.1 | Imparticion de Capacitacion | 1.81d? | 2011-02-02 | 2011-02-04 | 15 |  |  | 2011-02-02 | 2011-02-04 | 10d | 0d | finish no earlier than 2011-02-04 | Maria del Carmen Flota Leon [50%]; Patricia Martinez Guzman [50%] | 14.5h |  |
| 18 | 1.2.3.2 | Apoyo Logistico | 3.62d? | 2011-02-02 | 2011-02-08 | 17SS |  |  | 2011-02-02 | 2011-02-08 | 5.88d | 0d | start no earlier than 2011-02-01 | Carol Heredia Gracias [30%] | 8.7h |  |
| 19 | 1.2.3.3 | Apoyo Tecnico | 1.81d? | 2011-02-02 | 2011-02-04 | 18SS |  |  | 2011-02-02 | 2011-02-04 | 5.88d | 0d | finish no earlier than 2011-02-04 | Juan Alberto Alcudia Mendoza [20%]; Fausto Hernandez Gonzalez [20%] | 5.8h |  |
| 20 | 1.2.4 | **BELLOTA-JUJO, UO CARDENAS** | 1d? | 2011-02-04 | 2011-02-07 |  |  |  | 2011-02-04 | 2011-02-07 | 5.88d |  |  |  | 12h |  |
| 21 | 1.2.4.1 | Imparticion de Capacitacion | 1d? | 2011-02-04 | 2011-02-07 | 19 |  |  | 2011-02-04 | 2011-02-07 | 5.88d | 0d |  | Maria del Carmen Flota Leon [50%]; Patricia Martinez Guzman [50%] | 8h |  |
| 22 | 1.2.4.2 | Apoyo Logistico | 1d? | 2011-02-04 | 2011-02-07 | 21SS |  |  | 2011-02-04 | 2011-02-07 | 5.88d | 0d |  | Carol Heredia Gracias [30%] | 2.4h |  |
| 23 | 1.2.4.3 | Apoyo Tecnico | 0.5d? | 2011-02-04 | 2011-02-07 | 22SS |  |  | 2011-02-04 | 2011-02-07 | 5.88d | 0.88d |  | Fausto Hernandez Gonzalez [20%]; Juan Alberto Alcudia Mendoza [20%] | 1.6h |  |
| 24 | 1.2.5 | **CINCO PRESIDENTES, UO DELTA DEL TONALA** | 3.62d? | 2011-02-08 | 2011-02-11 |  |  |  | 2011-02-08 | 2011-02-11 | 1.38d |  |  |  | 49.3h |  |
| 25 | 1.2.5.1 | Imparticion de Capacitacion | 3.62d? | 2011-02-08 | 2011-02-11 | 23 |  |  | 2011-02-08 | 2011-02-11 | 5d | 0d | finish no earlier than 2011-02-11 | Maria del Carmen Flota Leon [50%]; Patricia Martinez Guzman [50%] | 29h |  |
| 26 | 1.2.5.2 | Apoyo Logistico | 3.62d? | 2011-02-08 | 2011-02-11 | 25SS |  |  | 2011-02-08 | 2011-02-11 | 1.38d | 0d | start no earlier than 2011-02-08 | Carol Heredia Gracias [30%] | 8.7h |  |
| 27 | 1.2.5.3 | Apoyo Tecnico | 3.62d? | 2011-02-08 | 2011-02-11 | 26SS |  |  | 2011-02-08 | 2011-02-11 | 1.38d |  | finish no earlier than 2011-02-11 | Fausto Hernandez Gonzalez [20%]; Jorge Alberto Alejandro Mendez [20%] | 11.6h |  |

Notes:
- 3: Visitas a los diferentes Activos y Unidades Operativas de la Region Sur para recolectar la informacion del Personal que asistira al Curso
- 4: Difusion del Curso de SPDIS mediante AVISOSPEP los dias Martes y Jueves de cada Semana

| ID | WBS | Task | Type | Duration | Start | Finish | Predecessors | Baseline 1 start | Baseline 1 finish | Total slack | Constraint | Resources | Work |
| --- | --- | --- | --- | --- | --- | --- | --- | --- | --- | --- | --- | --- | --- |
| 28 | 1.2.6 | **DIV. SUR, REGION SUR** |  | 3.62d? | 2011-02-15 | 2011-02-18 |  | 2011-02-15 | 2011-02-18 | 0d |  |  | 49.3h |
| 29 | 1.2.6.1 | Imparticion de Capacitacion |  | 3.62d? | 2011-02-15 | 2011-02-18 | 27 | 2011-02-15 | 2011-02-18 | 0d | finish no earlier than 2011-02-18 | Maria del Carmen Flota Leon [50%]; Patricia Martinez Guzman [50%] | 29h |
| 30 | 1.2.6.2 | Apoyo Logistico |  | 3.62d? | 2011-02-15 | 2011-02-18 | 29SS | 2011-02-15 | 2011-02-18 | 0d | finish no earlier than 2011-02-18 | Carol Heredia Gracias [30%] | 8.7h |
| 31 | 1.2.6.3 | Apoyo Tecnico |  | 3.62d? | 2011-02-15 | 2011-02-18 | 30SS | 2011-02-15 | 2011-02-18 | 0d | start no earlier than 2011-02-15 | Fausto Hernandez Gonzalez [20%]; Jorge Alberto Alejandro Mendez [20%] | 11.6h |
| 32 | 2 | FIN DE CAPACITACION EN LA REGION SUR | milestone | 0d | 2011-02-18 | 2011-02-18 |  | 2011-02-18 | 2011-02-18 | 0.62d | start no earlier than 2011-02-18 |  |  |
